# OEDL - Phase 4

Schedule from MS Project, 2002-09-16 to 2002-10-21, A marks actual dates.
Sigloo

## Calendars

- Standard: Mon-Fri 08:00-12:00, 13:00-17:00; Sat-Sun off.

## Resources

| Resource |
| --- |
| Lma |
| Aba |
| Fbi |
| Rvi |
| Sig |

## Schedule

| ID | WBS | Task | Duration | Start | Finish | Predecessors | Complete | Remaining | Total slack | Free slack | Constraint | Resources | Work | Actual work |
| --- | --- | --- | --- | --- | --- | --- | --- | --- | --- | --- | --- | --- | --- | --- |
| 1 | P1/5 | **P5 - Produit Final : "Conception"** | 26d? | 2002-09-16 A | 2002-10-21 |  | 57% | 11.21d? | 0d |  |  | Sig | 1632h | 938.2h |
| 3 | P1/5MP03 | **Management** | 26d | 2002-09-16 A | 2002-10-21 |  | 40% | 15.6d | 0d |  |  | Fbi | 288h | 115.2h |
| 4 | P1/5MP0304 | Réunion interne 1 | 1d | 2002-09-16 A | 2002-09-16 A |  | 100% |  |  |  | start no earlier than 2002-09-16 | Sig | 8h | 8h |
| 5 | P1/5MP0305 | Réunion suivi 1 | 1d | 2002-09-20 A | 2002-09-20 A | 4 | 100% |  |  |  | start no earlier than 2002-09-20 | Sig | 8h | 8h |
| 6 | P1/5MP0306 | Réunion interne 2 | 1d | 2002-09-23 A | 2002-09-23 A | 5 | 100% |  |  |  | start no earlier than 2002-09-23 | Sig | 8h | 8h |
| 7 | P1/5MP0307 | Réunion interne 3 | 1d | 2002-09-30 A | 2002-09-30 A | 6 | 100% |  |  |  | start no earlier than 2002-09-30 | Sig | 8h | 8h |
| 8 | P1/5MP0308 | Réunion suivi 2 | 1d | 2002-10-04 | 2002-10-04 | 7 |  |  | 10d |  | start no earlier than 2002-10-04 | Sig | 8h |  |
| 9 | P1/5MP0309 | Réunion interne 4 | 1d | 2002-10-07 | 2002-10-07 | 8 |  |  | 9d |  | start no earlier than 2002-10-07 | Sig | 8h |  |
| 10 | P1/5MP0310 | Réunion suivi 3 | 1d | 2002-10-11 | 2002-10-11 | 9 |  |  | 5d |  | start no earlier than 2002-10-11 | Sig | 8h |  |
| 11 | P1/5MP0311 | Réunion interne 5 | 1d | 2002-10-14 | 2002-10-14 | 10 |  |  | 4d |  | start no earlier than 2002-10-14 | Sig | 8h |  |
| 12 | P1/5MP0312 | Préparation de la soutenance | 1d | 2002-10-18 | 2002-10-18 | 11 |  |  | 0d |  | start no earlier than 2002-10-18 | Sig | 8h |  |
| 13 | P1/5MP0313 | Soutenance | 1d | 2002-10-21 | 2002-10-21 | 12 |  |  | 0d |  | start no earlier than 2002-10-18 | Sig | 8h |  |
| 15 | P1/5C | **Conception** | 24d? | 2002-09-16 A | 2002-10-17 |  | 59% | 9.82d? | 2d |  |  | Sig | 1136h | 704.65h |
| 16 | P1/5TT01 | **DCP** | 24d | 2002-09-16 A | 2002-10-17 |  | 60% | 9.6d | 2d |  |  | Sig | 416h | 283.2h |
| 17 | P1/5TT0102 | relecture | 7d | 2002-09-16 A | 2002-09-24 A |  | 100% |  |  |  | start no earlier than 2002-09-16 | Aba | 56h | 56h |
| 18 | P1/5TT0104 | correction de la forme | 7d | 2002-09-16 A | 2002-09-24 A | 17 | 100% |  |  |  | start no earlier than 2002-09-16 | Aba | 56h | 56h |
| 19 | P1/5TT0105 | correction du fond élémentaire | 7d | 2002-09-23 A | 2002-10-01 | 18 | 50% | 3.5d | 3.5d | 0d | start no earlier than 2002-09-23 | Sig | 56h | 28h |
| 20 | P1/5TT0106 | correction du fond synthèse | 7d | 2002-09-30 A | 2002-10-08 | 19 | 50% | 3.5d | 2d | 0d | start no earlier than 2002-09-30 | Aba | 56h | 28h |
| 21 | P1/5TT0107 | Relecture et affinement | 7d | 2002-10-09 | 2002-10-17 | 20 |  |  | 2d |  | start no earlier than 2002-10-07 |  |  |  |
| 22 | P1/5TT02 | **DCD** | 24d? | 2002-09-16 A | 2002-10-17 |  | 58% | 10d? | 2d |  |  | Sig | 528h | 308h |
| 23 | P1/5CD01 | écriture de régle de programmation | 7d | 2002-09-16 A | 2002-09-24 A |  | 100% |  |  |  | start no earlier than 2002-09-16 | Lma | 56h | 56h |
| 24 | P1/5TC0303 | packadging de l'application | 7d | 2002-09-16 A | 2002-09-24 A | 23 | 100% |  |  |  | start no earlier than 2002-09-16 | Lma | 56h | 56h |
| 25 | P1/5TC0304 | diagramme de classe avec commentaire | 7d | 2002-09-23 A | 2002-10-01 | 24 | 50% | 3.5d | 14d |  | start no earlier than 2002-09-23 | Sig | 56h | 28h |
| 26 | P1/5TC0202 | Synthése MCP MPD global | 7d | 2002-09-23 A | 2002-10-01 A |  | 100% |  |  |  | start no earlier than 2002-09-23 | Rvi | 56h | 56h |
| 27 | P1/5TT0205 | Intégration des squellettes | 7d? | 2002-09-30 | 2002-10-08 |  |  |  | 8d |  | start no earlier than 2002-09-30 | Sig | 56h |  |
| 28 | P1/5TT0206 | Relecture et affinement | 7d? | 2002-10-09 | 2002-10-17 | 27 |  |  | 2d |  | start no earlier than 2002-09-10 | Lma | 56h |  |
